# J1305 Scheduling_8

Schedule from MS Project, 2016-05-09 to 2017-05-01, 7.5 hours a day.
Alpheius Global Building Services

## Calendars

- Standard: Mon-Fri 07:30-12:30, 13:00-15:30; Sat-Sun off. Exceptions (off unless hours are given): 2016-12-19 to 2017-01-04 (End of year closure).

## Schedule

| ID | WBS | Task | Type | Duration | Start | Finish | Predecessors | Total slack | Free slack |
| --- | --- | --- | --- | --- | --- | --- | --- | --- | --- |
| 1 | 1 | **Planning** |  | 43d | 2016-05-09 | 2016-07-06 |  | 0d |  |
| 2 | 1.1 | Create architectural plans |  | 3w | 2016-05-09 | 2016-05-27 |  | 0d |  |
| 3 | 1.2 | Submit plans for approval |  | 1mo | 2016-05-30 | 2016-06-24 | 2 | 0d |  |
| 4 | 1.3 | Order materials |  | 8d | 2016-06-27 | 2016-07-06 | 3 | 0d |  |
| 5 | 1.4 | Planning Completed | milestone | 0d | 2016-07-06 | 2016-07-06 | 4, 2, 3 | 0d |  |
| 6 | 2 | **Site Works** |  | 27d | 2016-07-07 | 2016-08-12 |  | 0d |  |
| 7 | 2.1 | Erect fencing |  | 3d | 2016-07-07 | 2016-07-11 | 5 | 0d |  |
| 8 | 2.2 | Erect site buildings |  | 4d | 2016-07-12 | 2016-07-15 | 7 | 0d |  |
| 9 | 2.3 | Clear and level site |  | 3w | 2016-07-18 | 2016-08-05 | 8 | 0d |  |
| 10 | 2.4 | Prepare drainage infrastructure |  | 1w | 2016-08-08 | 2016-08-12 | 9 | 0d |  |
| 11 | 2.5 | Prepare cabling infrastructure |  | 1w | 2016-08-08 | 2016-08-12 | 9 | 0d |  |
| 12 | 2.6 | Site Works Completed | milestone | 0d | 2016-08-12 | 2016-08-12 | 7, 8, 9, 10, 11 | 0d |  |
| 13 | 3 | **Building Construction** |  | 124d | 2016-08-15 | 2017-02-21 |  | 0d |  |
| 14 | 3.1 | Pour foundations |  | 4d | 2016-08-15 | 2016-08-18 | 12 | 0d |  |
| 15 | 3.2 | Erect steelwork |  | 3mo | 2016-08-19 | 2016-11-10 | 14 | 0d |  |
| 16 | 3.3 | Erect wall |  | 2mo | 2016-11-11 | 2017-01-24 | 15 | 0d |  |
| 17 | 3.4 | Install roofing superstructure |  | 2w | 2017-01-25 | 2017-02-07 | 16 | 0d |  |
| 18 | 3.5 | Install roofing retracting mechanism |  | 1w | 2017-02-08 | 2017-02-14 | 17 | 0d |  |
| 19 | 3.6 | Erect seating tiers |  | 2w | 2017-02-08 | 2017-02-21 | 18SS | 0d |  |
| 20 | 3.7 | Building Construction Completed | milestone | 0d | 2017-02-21 | 2017-02-21 | 14, 15, 16, 17, 18, 19 | 0d |  |
| 21 | 4 | **Fit Out** |  | 35d | 2017-02-22 | 2017-04-11 |  | 0d |  |
| 22 | 4.1 | Fit all windows and doors |  | 2w | 2017-02-22 | 2017-03-07 | 20 | 25d |  |
| 23 | 4.2 | Install electrical cabling |  | 1w | 2017-02-22 | 2017-02-28 | 20 | 20d | 0d |
| 24 | 4.3 | Install electrical fittings and fixtures |  | 2w | 2017-03-01 | 2017-03-14 | 23 | 20d |  |
| 25 | 4.4 | Install all plumbing |  | 2w | 2017-02-22 | 2017-03-07 | 20 | 20d | 0d |
| 26 | 4.5 | Install plumbing fittings and fixtures |  | 1w | 2017-03-08 | 2017-03-14 | 25 | 20d |  |
| 27 | 4.6 | Lay astro turf |  | 1w | 2017-02-22 | 2017-02-28 | 20 | 30d |  |
| 28 | 4.7 | Erect handrails and fencing |  | 2w | 2017-02-22 | 2017-03-07 | 20 | 0d |  |
| 29 | 4.8 | Paint rooms, fixtures, fittings, etc |  | 1mo | 2017-03-08 | 2017-04-04 | 28 | 0d |  |
| 30 | 4.9 | Install PA system |  | 2d | 2017-03-01 | 2017-03-02 | 23 | 23d |  |
| 31 | 4.10 | Install video imaging equipment |  | 3d | 2017-03-01 | 2017-03-03 | 23 | 22d |  |
| 32 | 4.11 | Fit out control room |  | 1w | 2017-04-05 | 2017-04-11 | 29, 30, 31 | 0d |  |
| 33 | 4.12 | Fit Out Completed | milestone | 0d | 2017-04-11 | 2017-04-11 | 22, 23, 24, 25, 26, 27, 28, 29, 30, 31, 32 | 0d |  |

| ID | WBS | Task | Type | Duration | Start | Finish | Predecessors | Total slack |
| --- | --- | --- | --- | --- | --- | --- | --- | --- |
| 34 | 5 | **Commissioning** |  | 14d | 2017-04-12 | 2017-05-01 |  | 0d |
| 35 | 5.1 | Test roof mechanism |  | 1w | 2017-04-12 | 2017-04-18 | 33 | 0d |
| 36 | 5.2 | Test PA system |  | 2d | 2017-04-12 | 2017-04-13 | 33 | 3d |
| 37 | 5.3 | Test video imaging equipment |  | 2d | 2017-04-12 | 2017-04-13 | 33 | 3d |
| 38 | 5.4 | Test control room equipment |  | 1w | 2017-04-19 | 2017-04-25 | 35, 36, 37 | 0d |
| 39 | 5.5 | Obtain official occupancy certificates |  | 1d | 2017-04-26 | 2017-04-26 | 38 | 0d |
| 40 | 5.6 | Obtain safety certification |  | 2d | 2017-04-27 | 2017-04-28 | 39 | 0d |
| 41 | 5.7 | Official opening |  | 1d | 2017-05-01 | 2017-05-01 | 40 | 0d |
| 42 | 5.8 | Commissioning Completed | milestone | 0d | 2017-05-01 | 2017-05-01 | 35, 36, 37, 38, 39, 40, 41 | 0d |
