# J1308 Assignment_2

Schedule from MS Project, 2016-05-09 to 2017-04-21, 7.5 hours a day.
Alpheius Global Building Services

## Calendars

- Standard: Mon-Fri 07:30-12:30, 13:00-15:30; Sat-Sun off. Exceptions (off unless hours are given): 2016-12-19 to 2017-01-04 (End of year closure).

## Resources

| Resource | Group | Unit | Notes |
| --- | --- | --- | --- |
| Architect | Consultant |  | The architect will be attending World Architects Day festivities in Sao Paulo between June 25 and July 10. |
| Draftsperson | Staff |  |  |
| Building Clerk | Staff |  |  |
| Supervisor | Staff |  |  |
| Rigger | Wages |  |  |
| Boilermaker | Wages |  |  |
| Welder | Wages |  |  |
| Carpenter | Wages |  |  |
| Painter | Wages |  |  |
| Labourer | Wages |  |  |
| Driver | Wages |  |  |
| No Barrier Fencing | Contractor |  |  |
| Rock Solid Concrete | Contractor |  |  |
| Listen Ear Audio | Contractor |  |  |
| In Focus Video | Contractor |  |  |
| Pure Grass Turf | Contractor |  |  |
| Building Inspector | Government |  |  |
| High Jib Crane | Equipment |  |  |
| Grader | Equipment |  |  |
| Air Compressor | Equipment |  |  |
| Utility | Equipment |  |  |
| Astro Turf | Material | Square Metre |  |
| Painter | Material | Litre |  |
| Building Permit | Cost |  |  |
| End of Project Party | Cost |  |  |

## Schedule

| ID | WBS | Task | Type | Duration | Start | Finish | Predecessors | Total slack | Free slack | Resources | Work |
| --- | --- | --- | --- | --- | --- | --- | --- | --- | --- | --- | --- |
| 1 | 1 | **Planning** |  | 43d | 2016-05-09 | 2016-07-06 |  | 0d |  |  | 337.5h |
| 2 | 1.1 | Create architectural plans |  | 3w | 2016-05-09 | 2016-05-27 |  | 0d |  | Architect; Draftsperson [200%] | 337.5h |
| 3 | 1.2 | Submit plans for approval |  | 1mo | 2016-05-30 | 2016-06-24 | 2 | 0d |  |  |  |
| 4 | 1.3 | Order materials |  | 8d | 2016-06-27 | 2016-07-06 | 3 | 0d |  |  |  |
| 5 | 1.4 | Planning Completed | milestone | 0d | 2016-07-06 | 2016-07-06 | 4, 2, 3 | 0d |  |  |  |
| 6 | 2 | **Site Works** |  | 27d | 2016-07-07 | 2016-08-12 |  | 0d |  |  |  |
| 7 | 2.1 | Erect fencing |  | 3d | 2016-07-07 | 2016-07-11 | 5 | 0d |  |  |  |
| 8 | 2.2 | Erect site buildings |  | 4d | 2016-07-12 | 2016-07-15 | 7 | 0d |  |  |  |
| 9 | 2.3 | Clear and level site |  | 3w | 2016-07-18 | 2016-08-05 | 8 | 0d |  |  |  |
| 10 | 2.4 | Prepare drainage infrastructure |  | 1w | 2016-08-08 | 2016-08-12 | 9 | 0d |  |  |  |
| 11 | 2.5 | Prepare cabling infrastructure |  | 1w | 2016-08-08 | 2016-08-12 | 9 | 0d |  |  |  |
| 12 | 2.6 | Site Works Completed | milestone | 0d | 2016-08-12 | 2016-08-12 | 7, 8, 9, 10, 11 | 0d |  |  |  |
| 13 | 3 | **Building Construction** |  | 120d | 2016-08-15 | 2017-02-15 |  | 0d |  |  |  |
| 14 | 3.1 | Pour foundations |  | 4d | 2016-08-15 | 2016-08-18 | 12 | 0d |  |  |  |
| 15 | 3.2 | Erect steelwork |  | 3mo | 2016-08-23 | 2016-11-14 | 14FS+100eh | 0d |  |  |  |
| 16 | 3.3 | Erect wall |  | 2mo | 2016-11-07 | 2017-01-18 | 15FS-1% | 0d |  |  |  |
| 17 | 3.4 | Install roofing superstructure |  | 2w | 2017-01-19 | 2017-02-01 | 16 | 0d |  |  |  |
| 18 | 3.5 | Install roofing retracting mechanism |  | 1w | 2017-02-02 | 2017-02-08 | 17 | 0d |  |  |  |
| 19 | 3.6 | Erect seating tiers |  | 2w | 2017-02-02 | 2017-02-15 | 18SS | 0d |  |  |  |
| 20 | 3.7 | Building Construction Completed | milestone | 0d | 2017-02-15 | 2017-02-15 | 14, 15, 16, 17, 18, 19 | 0d |  |  |  |
| 21 | 4 | **Fit Out** |  | 33d | 2017-02-16 | 2017-04-03 |  | 0d |  |  |  |
| 22 | 4.1 | Fit all windows and doors |  | 2w | 2017-02-16 | 2017-03-01 | 20 | 23d |  |  |  |
| 23 | 4.2 | Install electrical cabling |  | 1w | 2017-02-16 | 2017-02-22 | 20 | 18d | 0d |  |  |
| 24 | 4.3 | Install electrical fittings and fixtures |  | 2w | 2017-02-23 | 2017-03-08 | 23 | 18d |  |  |  |
| 25 | 4.4 | Install all plumbing |  | 2w | 2017-02-16 | 2017-03-01 | 20 | 18d | 0d |  |  |
| 26 | 4.5 | Install plumbing fittings and fixtures |  | 1w | 2017-03-02 | 2017-03-08 | 25 | 18d |  |  |  |
| 27 | 4.6 | Lay astro turf |  | 1w | 2017-02-16 | 2017-02-22 | 20 | 28d |  |  |  |
| 28 | 4.7 | Erect handrails and fencing |  | 2w | 2017-02-16 | 2017-03-01 | 20 | 0d |  |  |  |
| 29 | 4.8 | Paint rooms, fixtures, fittings, etc |  | 1mo | 2017-02-28 | 2017-03-27 | 28FS-2d | 0d |  |  |  |
| 30 | 4.9 | Install PA system |  | 2d | 2017-02-23 | 2017-02-24 | 23 | 21d |  |  |  |
| 31 | 4.10 | Install video imaging equipment |  | 3d | 2017-02-23 | 2017-02-27 | 23 | 20d |  |  |  |
| 32 | 4.11 | Fit out control room |  | 1w | 2017-03-28 | 2017-04-03 | 29, 30, 31 | 0d |  |  |  |
| 33 | 4.12 | Fit Out Completed | milestone | 0d | 2017-04-03 | 2017-04-03 | 22, 23, 24, 25, 26, 27, 28, 29, 30, 31, 32 | 0d |  |  |  |

| ID | WBS | Task | Type | Duration | Start | Finish | Predecessors | Total slack |
| --- | --- | --- | --- | --- | --- | --- | --- | --- |
| 34 | 5 | **Commissioning** |  | 14d | 2017-04-04 | 2017-04-21 |  | 0d |
| 35 | 5.1 | Test roof mechanism |  | 1w | 2017-04-04 | 2017-04-10 | 33 | 0d |
| 36 | 5.2 | Test PA system |  | 2d | 2017-04-04 | 2017-04-05 | 33 | 3d |
| 37 | 5.3 | Test video imaging equipment |  | 2d | 2017-04-04 | 2017-04-05 | 33 | 3d |
| 38 | 5.4 | Test control room equipment |  | 1w | 2017-04-11 | 2017-04-17 | 35, 36, 37 | 0d |
| 39 | 5.5 | Obtain official occupancy certificates |  | 1d | 2017-04-18 | 2017-04-18 | 38 | 0d |
| 40 | 5.6 | Obtain safety certification |  | 2d | 2017-04-19 | 2017-04-20 | 39 | 0d |
| 41 | 5.7 | Official opening |  | 1d | 2017-04-21 | 2017-04-21 | 40 | 0d |
| 42 | 5.8 | Commissioning Completed | milestone | 0d | 2017-04-21 | 2017-04-21 | 35, 36, 37, 38, 39, 40, 41 | 0d |
