# J1310 Materials_6

Schedule from MS Project, 2016-05-09 to 2017-05-08, 7.5 hours a day.
Alpheius Global Building Services

## Calendars

- Standard: Mon-Fri 07:30-12:30, 13:00-15:30; Sat-Sun off. Exceptions (off unless hours are given): 2016-12-19 to 2017-01-04 (End of year closure).

## Resources

| Resource | Group | Unit | Notes |
| --- | --- | --- | --- |
| Architect | Consultant |  | The architect will be attending World Architects Day festivities in Sao Paulo between June 25 and July 10. |
| Draftsperson | Staff |  |  |
| Building Clerk | Staff |  |  |
| Supervisor | Staff |  |  |
| Rigger | Wages |  |  |
| Boilermaker | Wages |  |  |
| Welder | Wages |  |  |
| Carpenter | Wages |  |  |
| Painter | Wages |  |  |
| Labourer | Wages |  |  |
| Driver | Wages |  |  |
| No Barrier Fencing | Contractor |  |  |
| Rock Solid Concrete | Contractor |  |  |
| Listen Ear Audio | Contractor |  |  |
| In Focus Video | Contractor |  |  |
| Pure Grass Turf | Contractor |  |  |
| Building Inspector | Government |  |  |
| High Jib Crane | Equipment |  |  |
| Grader | Equipment |  |  |
| Air Compressor | Equipment |  |  |
| Utility | Equipment |  |  |
| Astro Turf | Material | Square Metre |  |
| Paint | Material | Litre |  |
| Building Permit | Cost |  |  |
| End of Project Party | Cost |  |  |
| Plumber |  |  |  |
| Electrician |  |  |  |
| On The Hammer | Contract Labour |  |  |
| Diesel Fuel | Fuel | Litre |  |
| Unleaded Petrol | Fuel | litre |  |

## Schedule

| ID | WBS | Task | Type | Duration | Start | Finish | Predecessors | Total slack | Free slack | Resources | Work |
| --- | --- | --- | --- | --- | --- | --- | --- | --- | --- | --- | --- |
| 1 | 1 | **Planning** |  | 43d | 2016-05-09 | 2016-07-06 |  | 0d |  |  | 441.12h |
| 2 | 1.1 | Create architectural plans |  | 3w | 2016-05-09 | 2016-05-27 |  | 0d |  | Architect; Draftsperson; Building Clerk [25%] | 253.12h |
| 3 | 1.2 | Submit plans for approval |  | 1mo | 2016-05-30 | 2016-06-24 | 2 | 0d |  | Architect | 8h |
| 4 | 1.3 | Order materials |  | 8d | 2016-06-27 | 2016-07-06 | 3 | 0d |  | Draftsperson; Building Clerk | 67.5h |
| 5 | 1.4 | Planning Completed | milestone | 0d | 2016-07-06 | 2016-07-06 | 4, 2, 3 | 0d |  |  |  |
| 6 | 2 | **Site Works** |  | 27d | 2016-07-07 | 2016-08-12 |  | 0d |  |  | 975h |
| 7 | 2.1 | Erect fencing |  | 3d | 2016-07-07 | 2016-07-11 | 5 | 0d |  | No Barrier Fencing | 22.5h |
| 8 | 2.2 | Erect site buildings |  | 4d | 2016-07-12 | 2016-07-15 | 7 | 0d |  | Supervisor; Carpenter [400%]; Labourer [800%] | 390h |
| 9 | 2.3 | Clear and level site |  | 3w | 2016-07-18 | 2016-08-05 | 8 | 0d |  | Driver [200%]; Grader [200%]; Supervisor; Diesel Fuel [16 Litre] | 337.5h |
| 10 | 2.4 | Prepare drainage infrastructure |  | 1w | 2016-08-08 | 2016-08-12 | 9 | 0d |  | Supervisor [50%]; Plumber [200%] | 93.75h |
| 11 | 2.5 | Prepare cabling infrastructure |  | 1w | 2016-08-08 | 2016-08-12 | 9 | 0d |  | Supervisor [50%]; Electrician [300%] | 131.25h |
| 12 | 2.6 | Site Works Completed | milestone | 0d | 2016-08-12 | 2016-08-12 | 7, 8, 9, 10, 11 | 0d |  |  |  |
| 13 | 3 | **Building Construction** |  | 131d | 2016-08-15 | 2017-03-02 |  | 0d |  |  | 21236.2h |
| 14 | 3.1 | Pour foundations |  | 4d | 2016-08-15 | 2016-08-18 | 12 | 0d |  | Rock Solid Concrete | 30h |
| 15 | 3.2 | Erect steelwork |  | 3mo | 2016-08-23 | 2016-11-14 | 14FS+100eh | 0d |  | Supervisor [50%]; Rigger [500%]; Boilermaker [600%]; Welder [500%]; Labourer [600%]; Driver [200%]; High Jib Crane; Utility; Diesel Fuel [12 Litre]; Unleaded Petrol [4 litre] | 12375h |
| 16 | 3.3 | Erect wall |  | 2mo | 2016-11-15 | 2017-01-26 | 15 | 0d |  | Supervisor [50%]; Carpenter [600%]; Labourer [400%]; Driver; Grader; Air Compressor; Electrician [75%]; Plumber [25%]; On The Hammer; Diesel Fuel [14 Litre] | 4650h |
| 17 | 3.4 | Install roofing superstructure |  | 2w | 2017-01-27 | 2017-02-09 | 16 | 0d |  | Supervisor [50%]; Rigger [500%]; Boilermaker [500%]; Welder [300%]; Labourer [500%]; Driver [200%]; High Jib Crane; Utility; Air Compressor; Plumber [50%]; Diesel Fuel [18 Litre]; Unleaded Petrol [4 litre] | 1800h |
| 18 | 3.5 | Install roofing retracting mechanism |  | 1w | 2017-02-10 | 2017-02-16 | 17 | 0d |  | Supervisor [50%]; Welder; Boilermaker [200%]; Rigger [200%]; Electrician [200%]; Driver; High Jib Crane; Diesel Fuel [12 Litre] | 356.25h |
| 19 | 3.6 | Erect seating tiers |  | 3w | 2017-02-10 | 2017-03-02 | 18SS | 0d |  | Supervisor [50%]; Carpenter [600%]; Welder [200%]; Boilermaker [200%]; Labourer [700%]; Driver; Utility; Air Compressor; Unleaded Petrol [4 litre]; Diesel Fuel [6 Litre] | 2025h |
| 20 | 3.7 | Building Construction Completed | milestone | 0d | 2017-03-02 | 2017-03-02 | 14, 15, 16, 17, 18, 19 | 0d |  |  |  |
| 21 | 4 | **Fit Out** |  | 33d | 2017-03-03 | 2017-04-18 |  | 0d |  |  | 2737.5h |
| 22 | 4.1 | Fit all windows and doors |  | 2w | 2017-03-03 | 2017-03-16 | 20 | 23d |  | Carpenter [500%]; Labourer [200%] | 525h |
| 23 | 4.2 | Install electrical cabling |  | 1w | 2017-03-03 | 2017-03-09 | 20 | 18d | 0d | Electrician [300%]; Labourer [200%] | 187.5h |
| 24 | 4.3 | Install electrical fittings and fixtures |  | 2w | 2017-03-10 | 2017-03-23 | 23 | 18d |  | Electrician [300%] | 225h |
| 25 | 4.4 | Install all plumbing |  | 2w | 2017-03-03 | 2017-03-16 | 20 | 18d | 0d | Plumber [200%]; Labourer [200%] | 300h |
| 26 | 4.5 | Install plumbing fittings and fixtures |  | 1w | 2017-03-17 | 2017-03-23 | 25 | 18d |  | Plumber [200%] | 75h |
| 27 | 4.6 | Lay astro turf |  | 1w | 2017-03-03 | 2017-03-09 | 20 | 28d |  | Pure Grass Turf; Astro Turf [17850 Square Metre] | 37.5h |
| 28 | 4.7 | Erect handrails and fencing |  | 2w | 2017-03-03 | 2017-03-16 | 20 | 0d |  | Welder [400%]; Boilermaker [200%] | 450h |
| 29 | 4.8 | Paint rooms, fixtures, fittings, etc |  | 1mo | 2017-03-15 | 2017-04-11 | 28FS-2d | 0d |  | Painter [500%]; Paint [1500 Litre] | 750h |
| 30 | 4.9 | Install PA system |  | 2d | 2017-03-10 | 2017-03-13 | 23 | 21d |  | Listen Ear Audio | 15h |
| 31 | 4.10 | Install video imaging equipment |  | 3d | 2017-03-10 | 2017-03-14 | 23 | 20d |  | In Focus Video | 22.5h |
| 32 | 4.11 | Fit out control room |  | 1w | 2017-04-12 | 2017-04-18 | 29, 30, 31 | 0d |  | Electrician [200%]; Listen Ear Audio; In Focus Video | 150h |
| 33 | 4.12 | Fit Out Completed | milestone | 0d | 2017-04-18 | 2017-04-18 | 22, 23, 24, 25, 26, 27, 28, 29, 30, 31, 32 | 0d |  |  |  |

| ID | WBS | Task | Type | Duration | Start | Finish | Predecessors | Total slack | Resources | Work |
| --- | --- | --- | --- | --- | --- | --- | --- | --- | --- | --- |
| 34 | 5 | **Commissioning** |  | 14d | 2017-04-19 | 2017-05-08 |  | 0d |  | 367.5h |
| 35 | 5.1 | Test roof mechanism |  | 1w | 2017-04-19 | 2017-04-25 | 33 | 0d | Supervisor; Electrician [200%]; Rigger | 150h |
| 36 | 5.2 | Test PA system |  | 2d | 2017-04-19 | 2017-04-20 | 33 | 3d | Listen Ear Audio | 15h |
| 37 | 5.3 | Test video imaging equipment |  | 2d | 2017-04-19 | 2017-04-20 | 33 | 3d | In Focus Video | 15h |
| 38 | 5.4 | Test control room equipment |  | 1w | 2017-04-26 | 2017-05-02 | 35, 36, 37 | 0d | Supervisor; Listen Ear Audio [20%]; In Focus Video [20%]; Architect; Electrician [200%] | 165h |
| 39 | 5.5 | Obtain official occupancy certificates |  | 1d | 2017-05-03 | 2017-05-03 | 38 | 0d | Architect; Building Clerk; Supervisor | 22.5h |
| 40 | 5.6 | Obtain safety certification |  | 2d | 2017-05-04 | 2017-05-05 | 39 | 0d |  |  |
| 41 | 5.7 | Official opening |  | 1d | 2017-05-08 | 2017-05-08 | 40 | 0d |  |  |
| 42 | 5.8 | Commissioning Completed | milestone | 0d | 2017-05-08 | 2017-05-08 | 35, 36, 37, 38, 39, 40, 41 | 0d |  |  |
