# J1313 Tracking_1

Schedule from MS Project, 2016-05-09 to 2017-04-29, 7.5 hours a day, costs in $.
Alpheius Global Building Services

## Calendars

- Standard: Mon-Fri 07:30-12:30, 13:00-15:30; Sat-Sun off. Exceptions (off unless hours are given): 2016-12-19 to 2017-01-04 (End of year closure).

## Resources

| Resource | Group | Unit | Rate | Cost per use | Notes |
| --- | --- | --- | --- | --- | --- |
| Architect | Consultant |  | 160 |  | The architect will be attending World Architects Day festivities in Sao Paulo between June 25 and July 10. |
| Draftsperson | Staff |  | 24.62 |  |  |
| Building Clerk | Staff |  | 21.54 |  |  |
| Supervisor | Staff |  | 23.08 |  |  |
| Rigger | Wages |  | 18.95 |  |  |
| Boilermaker | Wages |  | 20.66 |  |  |
| Welder | Wages |  | 20.25 |  |  |
| Carpenter | Wages |  | 21.5 |  |  |
| Painter | Wages |  | 12.9 |  |  |
| Labourer | Wages |  | 15.5 |  |  |
| Driver | Wages |  | 17.56 |  |  |
| No Barrier Fencing | Contractor |  |  |  |  |
| Rock Solid Concrete | Contractor |  |  |  |  |
| Listen Ear Audio | Contractor |  | 116.8 |  |  |
| In Focus Video | Contractor |  | 178 |  |  |
| Pure Grass Turf | Contractor |  | 195 |  |  |
| Building Inspector | Government |  |  |  |  |
| High Jib Crane | Equipment |  | 360 | 1200 |  |
| Grader | Equipment |  | 208.67 | 600 |  |
| Air Compressor | Equipment |  | 170.67 | 200 |  |
| Utility | Equipment |  | 28.67 | 67 |  |
| Astro Turf | Material | Square Metre | 65.27 |  |  |
| Paint | Material | Litre | 8.76 |  |  |
| Building Permit | Cost |  |  |  |  |
| End of Project Party | Cost |  |  |  |  |
| Plumber |  |  | 22.65 |  |  |
| Electrician |  |  | 21.56 |  |  |
| On The Hammer | Contract Labour |  | 65.25 | 75 |  |
| Diesel Fuel | Fuel | Litre | 1.89 |  |  |
| Unleaded Petrol | Fuel | litre | 1.76 |  |  |

## Schedule

| ID | WBS | Task | Type | Duration | Start | Finish | Predecessors | Total slack | Free slack | Deadline | Resources | Work | Cost |
| --- | --- | --- | --- | --- | --- | --- | --- | --- | --- | --- | --- | --- | --- |
| 1 | 1 | **Planning** |  | 43d | 2016-05-09 | 2016-07-06 |  | 0d |  |  |  | 328.62h | 29,078.85 |
| 2 | 1.1 | Create architectural plans |  | 3w | 2016-05-09 | 2016-05-27 |  | 0d |  |  | Architect; Draftsperson; Building Clerk [25%] | 253.12h | 21,375 |
| 3 | 1.2 | Submit plans for approval |  | 1mo | 2016-05-30 | 2016-06-24 | 2 | 0d |  | 2016-06-24 | Architect; Building Permit [0.1%] | 8h | 6,100 |
| 4 | 1.3 | Order materials |  | 8d | 2016-06-27 | 2016-07-06 | 3 | 0d |  |  | Draftsperson; Building Clerk | 67.5h | 1,603.85 |
| 5 | 1.4 | Planning Completed | milestone | 0d | 2016-07-06 | 2016-07-06 | 4, 2, 3 | 0d |  |  |  |  |  |
| 6 | 2 | **Site Works** |  | 27d | 2016-07-07 | 2016-08-12 |  | 0d |  |  |  | 975h | 60,530.6 |
| 7 | 2.1 | Erect fencing |  | 3d | 2016-07-07 | 2016-07-11 | 5 | 0d |  |  | No Barrier Fencing | 22.5h | 15,900 |
| 8 | 2.2 | Erect site buildings |  | 4d | 2016-07-12 | 2016-07-15 | 7 | 0d |  |  | Supervisor; Carpenter [400%]; Labourer [800%] | 390h | 6,992.31 |
| 9 | 2.3 | Clear and level site |  | 3w | 2016-07-18 | 2016-08-05 | 8 | 0d |  |  | Driver [200%]; Grader [200%]; Supervisor; Diesel Fuel [16 Litre] | 337.5h | 32,648.65 |
| 10 | 2.4 | Prepare drainage infrastructure |  | 1w | 2016-08-08 | 2016-08-12 | 9 | 0d |  |  | Supervisor [50%]; Plumber [200%] | 93.75h | 2,131.44 |
| 11 | 2.5 | Prepare cabling infrastructure |  | 1w | 2016-08-08 | 2016-08-12 | 9 | 0d |  |  | Supervisor [50%]; Electrician [300%] | 131.25h | 2,858.19 |
| 12 | 2.6 | Site Works Completed | milestone | 0d | 2016-08-12 | 2016-08-12 | 7, 8, 9, 10, 11 | 0d |  |  |  |  |  |
| 13 | 3 | **Building Construction** |  | 131d | 2016-08-15 | 2017-03-02 |  | 0d |  |  |  | 21236.2h | 1,676,814.16 |
| 14 | 3.1 | Pour foundations |  | 4d | 2016-08-15 | 2016-08-18 | 12 | 0d |  |  | Rock Solid Concrete | 30h | 895,000 |
| 15 | 3.2 | Erect steelwork |  | 3mo | 2016-08-23 | 2016-11-14 | 14FS+100eh | 0d |  |  | Supervisor [50%]; Rigger [500%]; Boilermaker [600%]; Welder [500%]; Labourer [600%]; Driver [200%]; High Jib Crane; Utility; Diesel Fuel [12 Litre]; Unleaded Petrol [4 litre] | 12375h | 409,162.81 |
| 16 | 3.3 | Erect wall |  | 2mo | 2016-11-15 | 2017-01-26 | 15 | 0d |  |  | Supervisor [50%]; Carpenter [600%]; Labourer [400%]; Driver; Grader; Air Compressor; Electrician [75%]; Plumber [25%]; On The Hammer; Diesel Fuel [14 Litre] | 4650h | 218,640.89 |
| 17 | 3.4 | Install roofing superstructure |  | 2w | 2017-01-27 | 2017-02-09 | 16 | 0d |  |  | Supervisor [50%]; Rigger [500%]; Boilermaker [500%]; Welder [300%]; Labourer [500%]; Driver [200%]; High Jib Crane; Utility; Air Compressor; Plumber [50%]; Diesel Fuel [18 Litre]; Unleaded Petrol [4 litre] | 1800h | 76,067.76 |
| 18 | 3.5 | Install roofing retracting mechanism |  | 1w | 2017-02-10 | 2017-02-16 | 17 | 0d |  |  | Supervisor [50%]; Welder; Boilermaker [200%]; Rigger [200%]; Electrician [200%]; Driver; High Jib Crane; Diesel Fuel [12 Litre] | 356.25h | 21,988.82 |
| 19 | 3.6 | Erect seating tiers |  | 3w | 2017-02-10 | 2017-03-02 | 18SS | 0d |  |  | Supervisor [50%]; Carpenter [600%]; Welder [200%]; Boilermaker [200%]; Labourer [700%]; Driver; Utility; Air Compressor; Unleaded Petrol [4 litre]; Diesel Fuel [6 Litre] | 2025h | 55,953.88 |
| 20 | 3.7 | Building Construction Completed | milestone | 0d | 2017-03-02 | 2017-03-02 | 14, 15, 16, 17, 18, 19 | 0d |  |  |  |  |  |
| 21 | 4 | **Fit Out** |  | 33d | 2017-03-03 | 2017-04-18 |  | 0d |  |  |  | 2737.5h | 1,251,065.25 |
| 22 | 4.1 | Fit all windows and doors |  | 2w | 2017-03-03 | 2017-03-16 | 20 | 23d |  |  | Carpenter [500%]; Labourer [200%] | 525h | 12,405 |
| 23 | 4.2 | Install electrical cabling |  | 1w | 2017-03-03 | 2017-03-09 | 20 | 18d | 0d |  | Electrician [300%]; Labourer [200%] | 187.5h | 3,588 |
| 24 | 4.3 | Install electrical fittings and fixtures |  | 2w | 2017-03-10 | 2017-03-23 | 23 | 18d |  |  | Electrician [300%] | 225h | 4,851 |
| 25 | 4.4 | Install all plumbing |  | 2w | 2017-03-03 | 2017-03-16 | 20 | 18d | 0d |  | Plumber [200%]; Labourer [200%] | 300h | 5,722.5 |
| 26 | 4.5 | Install plumbing fittings and fixtures |  | 1w | 2017-03-17 | 2017-03-23 | 25 | 18d |  |  | Plumber [200%] | 75h | 1,698.75 |
| 27 | 4.6 | Lay astro turf |  | 1w | 2017-03-03 | 2017-03-09 | 20 | 28d |  |  | Pure Grass Turf; Astro Turf [17850 Square Metre] | 37.5h | 1,172,382 |
| 28 | 4.7 | Erect handrails and fencing |  | 2w | 2017-03-03 | 2017-03-16 | 20 | 0d |  |  | Welder [400%]; Boilermaker [200%] | 450h | 9,174 |
| 29 | 4.8 | Paint rooms, fixtures, fittings, etc |  | 1mo | 2017-03-15 | 2017-04-11 | 28FS-2d | 0d |  |  | Painter [500%]; Paint [1500 Litre] | 750h | 22,815 |
| 30 | 4.9 | Install PA system |  | 2d | 2017-03-10 | 2017-03-13 | 23 | 21d |  |  | Listen Ear Audio | 15h | 1,752 |
| 31 | 4.10 | Install video imaging equipment |  | 3d | 2017-03-10 | 2017-03-14 | 23 | 20d |  |  | In Focus Video | 22.5h | 4,005 |
| 32 | 4.11 | Fit out control room |  | 1w | 2017-04-12 | 2017-04-18 | 29, 30, 31 | 0d |  |  | Electrician [200%]; Listen Ear Audio; In Focus Video | 150h | 12,672 |
| 33 | 4.12 | Fit Out Completed | milestone | 0d | 2017-04-18 | 2017-04-18 | 22, 23, 24, 25, 26, 27, 28, 29, 30, 31, 32 | 0d |  |  |  |  |  |

| ID | WBS | Task | Type | Duration | Start | Finish | Predecessors | Total slack | Constraint | Resources | Work | Cost |
| --- | --- | --- | --- | --- | --- | --- | --- | --- | --- | --- | --- | --- |
| 34 | 5 | **Commissioning** |  | 8d | 2017-04-19 | 2017-04-29 |  | 0d |  |  | 241.5h | 29,788.45 |
| 35 | 5.1 | Test roof mechanism |  | 3d | 2017-04-19 | 2017-04-21 | 33 | 0d |  | Supervisor; Electrician [200%]; Rigger | 90h | 1,915.81 |
| 36 | 5.2 | Test PA system |  | 2d | 2017-04-19 | 2017-04-20 | 33 | 1d |  | Listen Ear Audio | 15h | 1,752 |
| 37 | 5.3 | Test video imaging equipment |  | 2d | 2017-04-19 | 2017-04-20 | 33 | 1d |  | In Focus Video | 15h | 2,670 |
| 38 | 5.4 | Test control room equipment |  | 3d | 2017-04-24 | 2017-04-26 | 35, 36, 37 | 0d |  | Supervisor; Listen Ear Audio [20%]; In Focus Video [20%]; Architect; Electrician [200%] | 99h | 6,416.03 |
| 39 | 5.5 | Obtain official occupancy certificates |  | 1d | 2017-04-27 | 2017-04-27 | 38 | 0d |  | Architect; Building Clerk; Supervisor | 22.5h | 1,534.62 |
| 40 | 5.6 | Obtain safety certification |  | 1d | 2017-04-28 | 2017-04-28 | 39 | 0d |  |  |  |  |
| 41 | 5.7 | Official opening |  | 3eh | 2017-04-29 | 2017-04-29 | 40 | 0d | must start on 2017-04-29 | End of Project Party [0.1%] |  | 15,500 |
| 42 | 5.8 | Commissioning Completed | milestone | 0d | 2017-04-29 | 2017-04-29 | 35, 36, 37, 38, 39, 40, 41 | 0d |  |  |  |  |
