# The Rostadium Project.mpp

Schedule from MS Project, 2015-03-16 to 2016-02-16, 7.5 hours a day.
The Rostrum

## Calendars

- Standard: Mon-Fri 07:30-12:30, 13:00-15:30; Sat-Sun off.

## Schedule

| ID | WBS | Task | Type | Duration | Start | Finish | Predecessors | Total slack | Free slack |
| --- | --- | --- | --- | --- | --- | --- | --- | --- | --- |
| 1 | 1 | **Planning** |  | 43d | 2015-03-16 | 2015-05-13 |  | 0d |  |
| 2 | 1.1 | Create architectural plans |  | 3w | 2015-03-16 | 2015-04-03 |  | 0d |  |
| 3 | 1.2 | Submit plans for approval |  | 1mo | 2015-04-06 | 2015-05-01 | 2 | 0d |  |
| 4 | 1.3 | Order materials |  | 8d | 2015-05-04 | 2015-05-13 | 3 | 0d |  |
| 5 | 1.4 | Planning Completed | milestone | 0d | 2015-05-13 | 2015-05-13 | 2, 3, 4 | 0d |  |
| 6 | 2 | **Site Works** |  | 27d | 2015-05-14 | 2015-06-19 |  | 0d |  |
| 7 | 2.1 | Erect fencing |  | 3d | 2015-05-14 | 2015-05-18 | 5 | 0d |  |
| 8 | 2.2 | Erect site buildings |  | 4d | 2015-05-19 | 2015-05-22 | 7 | 0d |  |
| 9 | 2.3 | Clear and level site |  | 3w | 2015-05-25 | 2015-06-12 | 8 | 0d |  |
| 10 | 2.4 | Prepare drainage infrastructure |  | 1w | 2015-06-15 | 2015-06-19 | 9 | 0d |  |
| 11 | 2.5 | Prepare cabling infrastructure |  | 1w | 2015-06-15 | 2015-06-19 | 9 | 0d |  |
| 12 | 2.6 | Site Works Completed | milestone | 0d | 2015-06-19 | 2015-06-19 | 7, 8, 9, 10, 11 | 0d |  |
| 13 | 3 | **Building Construction** |  | 125d | 2015-06-22 | 2015-12-11 |  | 0d |  |
| 14 | 3.1 | Pour foundations |  | 4d | 2015-06-22 | 2015-06-25 | 12 | 0d |  |
| 15 | 3.2 | Erect steelwork |  | 3mo | 2015-06-30 | 2015-09-21 | 14FS+100eh | 0d |  |
| 16 | 3.3 | Erect wall |  | 2mo | 2015-09-14 | 2015-11-06 | 15FS-1% | 0d |  |
| 17 | 3.4 | Install roofing superstructure |  | 2w | 2015-11-09 | 2015-11-20 | 16 | 0d |  |
| 18 | 3.5 | Install roof retracting mechanism |  | 1w | 2015-11-23 | 2015-11-27 | 17 | 0d |  |
| 19 | 3.6 | Erect seating tiers |  | 3w | 2015-11-23 | 2015-12-11 | 18SS | 0d |  |
| 20 | 3.7 | Building Construction Completed | milestone | 0d | 2015-12-11 | 2015-12-11 | 14, 15, 16, 17, 18, 19 | 0d |  |
| 21 | 4 | **Fit Out** |  | 33d | 2015-12-14 | 2016-01-27 |  | 0d |  |
| 22 | 4.1 | Fit all windows and doors |  | 2w | 2015-12-14 | 2015-12-25 | 20 | 23d |  |
| 23 | 4.2 | Install electrical cabling |  | 1w | 2015-12-14 | 2015-12-18 | 20 | 18d | 0d |
| 24 | 4.3 | Install electrical fittings and fixtures |  | 2w | 2015-12-21 | 2016-01-01 | 23 | 18d |  |
| 25 | 4.4 | Install all plumbing |  | 2w | 2015-12-14 | 2015-12-25 | 20 | 18d | 0d |
| 26 | 4.5 | Install plumbing fittings and fixtures |  | 1w | 2015-12-28 | 2016-01-01 | 25 | 18d |  |
| 27 | 4.6 | Lay astro turf |  | 1w | 2015-12-14 | 2015-12-18 | 20 | 28d |  |
| 28 | 4.7 | Erect handrails and fencing |  | 2w | 2015-12-14 | 2015-12-25 | 20 | 0d |  |
| 29 | 4.8 | Paint rooms, fixtures, fittings, etc |  | 1mo | 2015-12-24 | 2016-01-20 | 28FS-2d | 0d |  |
| 30 | 4.9 | Install PA system |  | 2d | 2015-12-21 | 2015-12-22 | 23 | 21d |  |
| 31 | 4.10 | Install video imaging equipment |  | 3d | 2015-12-21 | 2015-12-23 | 23 | 20d |  |
| 32 | 4.11 | Fit out control room |  | 1w | 2016-01-21 | 2016-01-27 | 29, 30, 31 | 0d |  |
| 33 | 4.12 | Fit Out Completed | milestone | 0d | 2016-01-27 | 2016-01-27 | 22, 23, 24, 25, 26, 27, 28, 29, 30, 31, 32 | 0d |  |

| ID | WBS | Task | Type | Duration | Start | Finish | Predecessors | Total slack |
| --- | --- | --- | --- | --- | --- | --- | --- | --- |
| 34 | 5 | **Commissioning** |  | 14d | 2016-01-28 | 2016-02-16 |  | 0d |
| 35 | 5.1 | Test roof mechanism |  | 1w | 2016-01-28 | 2016-02-03 | 33 | 0d |
| 36 | 5.2 | Test PA system |  | 2d | 2016-01-28 | 2016-01-29 | 33 | 3d |
| 37 | 5.3 | Test video imaging equipment |  | 2d | 2016-01-28 | 2016-01-29 | 33 | 3d |
| 38 | 5.4 | Test control room equipment |  | 1w | 2016-02-04 | 2016-02-10 | 35, 36, 37 | 0d |
| 39 | 5.5 | Obtain official occupancy certificates |  | 1d | 2016-02-11 | 2016-02-11 | 38 | 0d |
| 40 | 5.6 | Obtain safety certification |  | 2d | 2016-02-12 | 2016-02-15 | 39 | 0d |
| 41 | 5.7 | Official opening |  | 1d | 2016-02-16 | 2016-02-16 | 40 | 0d |
| 42 | 5.8 | Commissioning Completed | milestone | 0d | 2016-02-16 | 2016-02-16 | 35, 36, 37, 38, 39, 40, 41 | 0d |
